# ProjectPlanASIC1.1detailed

How a schedule from MS Project changed from version to version. A marks actual dates.

## Version 1 (saved 2008-04-28, file ProjectPlanASIC1.1detailed.mpp)

| ID | WBS | Task | Duration | Start | Finish | Predecessors | Total float | Constraint |
| --- | --- | --- | --- | --- | --- | --- | --- | --- |
| 1 |  | Preliminary design review | 3h | 2008-05-01 | 2008-05-01 |  | 30.4d |  |
| 2 | 2 | **Bug fix 3 (level-shift logic)** | 10d | 2008-05-01 | 2008-05-15 |  | 17.5d |  |
| 3 |  | Schematic design | 0.5d | 2008-05-01 | 2008-05-01 |  | 17.5d |  |
| 4 |  | Simulation verification | 3d | 2008-05-01 | 2008-05-07 | 3 | 17.5d |  |
| 5 |  | Layout of new circuits | 1d | 2008-05-07 | 2008-05-08 | 4 | 17.5d |  |
| 6 |  | Insert into existing logic layout | 2d | 2008-05-08 | 2008-05-12 | 5 | 17.5d |  |
| 7 |  | DRC full logic block | 1.5d | 2008-05-12 | 2008-05-13 | 6 | 17.5d |  |
| 8 |  | LVS full logic block | 2d | 2008-05-14 | 2008-05-15 | 7 | 17.5d |  |
| 9 | 3 | **Bug fix 1&2 (biases)** | 1d | 2008-05-16 | 2008-05-16 | 2 | 17.5d |  |
| 10 |  | Schematic & simulation | 3h | 2008-05-16 | 2008-05-16 |  | 17.5d |  |
| 11 |  | Layout | 4.5h | 2008-05-16 | 2008-05-16 | 10 | 17.5d |  |
| 12 | 4 | **Change preSample pixels to preShape** | 5d | 2008-05-19 | 2008-05-23 | 9 | 17.5d |  |
| 13 |  | Schematic changes | 1d | 2008-05-19 | 2008-05-19 |  | 17.5d |  |
| 14 |  | Layout changes | 1d | 2008-05-20 | 2008-05-20 | 13 | 17.5d |  |
| 15 |  | DRC | 1d | 2008-05-21 | 2008-05-21 | 14 | 17.5d |  |
| 16 |  | LVS | 2d | 2008-05-22 | 2008-05-23 | 15 | 17.5d |  |
| 17 | 5 | **Change test structures to preShape** | 6d | 2008-05-26 | 2008-06-02 | 12 | 17.5d |  |
| 18 |  | Schematics | 1d | 2008-05-26 | 2008-05-26 |  | 17.5d |  |
| 19 |  | Layout | 2d | 2008-05-27 | 2008-05-28 | 18 | 17.5d |  |
| 20 |  | LVS | 1d | 2008-05-29 | 2008-05-29 | 19 | 17.5d |  |
| 21 |  | Integrate layout with top level | 2d | 2008-05-30 | 2008-06-02 | 20 | 17.5d |  |
| 22 | 6 | **Feasability study: Extra Trim bits** | 16d | 2008-05-08 | 2008-05-29 |  | 19.5d |  |
| 23 |  | Layout feasability | 2d | 2008-05-08 | 2008-05-09 |  | 19.5d | start no earlier than 2008-05-08 |
| 24 |  | Layout changes | 2w | 2008-05-12 | 2008-05-23 | 23 | 19.5d |  |
| 25 |  | DRC | 1d | 2008-05-26 | 2008-05-26 | 24 | 19.5d |  |
| 26 |  | LVS | 3d | 2008-05-27 | 2008-05-29 | 25 | 19.5d |  |
| 27 | 7 | **Top Level Checks** | 8.5d | 2008-06-03 | 2008-06-13 | 22, 17 | 17.5d |  |
| 28 |  | Integrate new pixel layout | 2d | 2008-06-03 | 2008-06-04 |  | 17.5d |  |
| 29 |  | DRC | 2d | 2008-06-05 | 2008-06-06 | 28 | 17.5d |  |
| 30 |  | LVS | 3d | 2008-06-09 | 2008-06-11 | 29 | 17.5d |  |
| 31 |  | Antennas | 0.5d | 2008-06-12 | 2008-06-12 | 30 | 17.5d |  |
| 32 |  | Regenerate fill | 1d | 2008-06-12 | 2008-06-13 | 31 | 17.5d |  |
| 33 |  | FDR | 6h | 2008-06-13 | 2008-06-13 |  | 1.2d | start no earlier than 2008-06-13 |
| 34 |  | Contingency & Final checks/changes | 3w | 2008-06-13 | 2008-07-10 | 33 | 1.2d |  |
| 35 |  | MPW Submission deadline | 1d | 2008-07-14 | 2008-07-14 | 34 | 0d | start no earlier than 2008-07-14 |

## Version 2 (data date 2008-05-13, saved 2008-05-15, file ProjectPlanASIC1.1detailed_update150508.mpp)

Last finish stays 2008-07-14. Complete tasks 0 → 6.

Added:

| ID | Task | Duration | Start | Finish | Predecessors |
| --- | --- | --- | --- | --- | --- |
| 28 | Integrate new test pixels | 2d | 2008-05-30 | 2008-06-02 | 27 |
| 29 | Integrate new logic cells | 2d | 2008-06-03 | 2008-06-04 | 28 |
| 36 | Update test pixels to new design | 2.5d | 2008-06-13 | 2008-06-18 |  |
| 37 | Final checks/changes | 2.5w | 2008-06-18 | 2008-07-10 | 36 |

Removed: 21 Integrate layout with top level

Changed:

| ID | Task | Start | Finish | Duration | Complete | Total float | Predecessors | Other |
| --- | --- | --- | --- | --- | --- | --- | --- | --- |
| 1 | Preliminary design review |  |  |  |  | 30.4d → 45.6d |  | baseline start none → 2008-05-01; baseline finish none → 2008-05-01 |
| 2 | **Bug fix 3 (level-shift logic)** | 2008-05-01 A | 2008-05-15 → 2008-05-14 A (-1d) | 10d → 6.5d | 0% → 100% | 17.5d → none |  | baseline start none → 2008-05-01; baseline finish none → 2008-05-15 |
| 3 | Schematic design | 2008-05-01 A | 2008-05-01 A |  | 0% → 100% | 17.5d → none |  | resources none → Jamie; baseline start none → 2008-05-01; baseline finish none → 2008-05-01 |
| 4 | Simulation verification | 2008-05-01 A | 2008-05-07 → 2008-05-06 A (-1d) | 3d → 2d | 0% → 100% | 17.5d → none |  | resources none → Jamie; baseline start none → 2008-05-01; baseline finish none → 2008-05-07 |
| 5 | Layout of new circuits | 2008-05-07 A | 2008-05-08 → 2008-05-07 A (-1d) |  | 0% → 100% | 17.5d → none |  | resources none → Jamie; baseline start none → 2008-05-07; baseline finish none → 2008-05-08 |
| 6 | Insert into existing logic layout | 2008-05-08 A | 2008-05-12 → 2008-05-08 A (-4d) | 2d → 1d | 0% → 100% | 17.5d → none |  | resources none → Jamie; baseline start none → 2008-05-08; baseline finish none → 2008-05-12 |
| 7 | DRC full logic block | 2008-05-12 → 2008-05-09 A (-3d) | 2008-05-13 → 2008-05-09 A (-4d) | 1.5d → 0.5d | 0% → 100% | 17.5d → none |  | resources none → Jamie; baseline start none → 2008-05-12; baseline finish none → 2008-05-13 |
| 8 | LVS full logic block | 2008-05-14 A | 2008-05-15 → 2008-05-14 A (-1d) | 2d → 0.5d | 0% → 100% | 17.5d → none |  | resources none → Jamie; baseline start none → 2008-05-14; baseline finish none → 2008-05-15 |
| 9 | **Bug fix 1&2 (biases)** | 2008-05-16 → 2008-05-27 (+11d) | 2008-05-16 → 2008-05-27 (+11d) |  |  |  | 2 → 12 | baseline start none → 2008-05-16; baseline finish none → 2008-05-16 |
| 10 | Schematic & simulation | 2008-05-16 → 2008-05-27 (+11d) | 2008-05-16 → 2008-05-27 (+11d) |  |  |  |  | resources none → Jamie; baseline start none → 2008-05-16; baseline finish none → 2008-05-16 |
| 11 | Layout | 2008-05-16 → 2008-05-27 (+11d) | 2008-05-16 → 2008-05-27 (+11d) |  |  |  |  | resources none → Jamie; baseline start none → 2008-05-16; baseline finish none → 2008-05-16 |
| 12 | **Change preSample pixels to preShape** | 2008-05-19 → 2008-05-20 (+1d) | 2008-05-23 → 2008-05-26 (+3d) |  |  |  | 9 → 17 | baseline start none → 2008-05-19; baseline finish none → 2008-05-23 |
| 13 | Schematic changes | 2008-05-19 → 2008-05-20 (+1d) | 2008-05-19 → 2008-05-20 (+1d) |  |  |  |  | resources none → Jamie; baseline start none → 2008-05-19; baseline finish none → 2008-05-19 |
| 14 | Layout changes | 2008-05-20 → 2008-05-21 (+1d) | 2008-05-20 → 2008-05-21 (+1d) |  |  |  |  | resources none → Jamie; baseline start none → 2008-05-20; baseline finish none → 2008-05-20 |
| 15 | DRC | 2008-05-21 → 2008-05-22 (+1d) | 2008-05-21 → 2008-05-22 (+1d) |  |  |  |  | resources none → Jamie; baseline start none → 2008-05-21; baseline finish none → 2008-05-21 |
| 16 | LVS | 2008-05-22 → 2008-05-23 (+1d) | 2008-05-23 → 2008-05-26 (+3d) |  |  |  |  | resources none → Jamie; baseline start none → 2008-05-22; baseline finish none → 2008-05-23 |
| 17 | **Change test structures to preShape** | 2008-05-26 → 2008-05-14 A (-12d) | 2008-06-02 → 2008-05-19 (-14d) | 6d → 4d | 0% → 13% |  | 12 → 2 | baseline start none → 2008-05-26; baseline finish none → 2008-06-02 |
| 18 | Schematics | 2008-05-26 → 2008-05-14 A (-12d) | 2008-05-26 → 2008-05-14 (-12d) |  | 0% → 50% |  |  | resources none → Jamie; baseline start none → 2008-05-26; baseline finish none → 2008-05-26 |
| 19 | Layout | 2008-05-27 → 2008-05-15 (-12d) | 2008-05-28 → 2008-05-16 (-12d) |  |  |  |  | resources none → Jamie; baseline start none → 2008-05-27; baseline finish none → 2008-05-28 |
| 20 | LVS | 2008-05-29 → 2008-05-19 (-10d) | 2008-05-29 → 2008-05-19 (-10d) |  |  |  |  | resources none → Jamie; baseline start none → 2008-05-29; baseline finish none → 2008-05-29 |
| 21 | **Feasability study: Extra Trim bits** | 2008-05-08 → 2008-05-19 (+11d) | 2008-05-29 → 2008-06-09 (+11d) |  |  | 19.5d → 21d |  | baseline start none → 2008-05-08; baseline finish none → 2008-05-29 |
| 22 | Layout feasability | 2008-05-08 → 2008-05-19 (+11d) | 2008-05-09 → 2008-05-20 (+11d) |  |  | 19.5d → 21d |  | constraint start no earlier than 2008-05-08 → start no earlier than 2008-05-19; resources none → Rebecca; baseline start none → 2008-05-08; baseline finish none → 2008-05-09 |
| 23 | Layout changes | 2008-05-12 → 2008-05-21 (+9d) | 2008-05-23 → 2008-06-03 (+11d) |  |  | 19.5d → 21d |  | resources none → Rebecca; baseline start none → 2008-05-12; baseline finish none → 2008-05-23 |
| 24 | DRC | 2008-05-26 → 2008-06-04 (+9d) | 2008-05-26 → 2008-06-04 (+9d) |  |  | 19.5d → 21d |  | resources none → Rebecca; baseline start none → 2008-05-26; baseline finish none → 2008-05-26 |
| 25 | LVS | 2008-05-27 → 2008-06-05 (+9d) | 2008-05-29 → 2008-06-09 (+11d) |  |  | 19.5d → 21d |  | resources none → Rebecca; baseline start none → 2008-05-27; baseline finish none → 2008-05-29 |
| 26 | **Top Level Changes & Checks** | 2008-06-03 → 2008-05-28 (-6d) |  | 8.5d → 12.5d |  |  | 21, 17 → 9 | was named Top Level Checks; baseline start none → 2008-06-03; baseline finish none → 2008-06-13 |
| 27 | Integrate new pixel layout | 2008-06-03 → 2008-05-28 (-6d) | 2008-06-04 → 2008-05-29 (-6d) |  |  |  |  | resources none → Jamie; baseline start none → 2008-06-03; baseline finish none → 2008-06-04 |
| 30 | DRC |  |  |  |  |  | 27 → 29 | resources none → Jamie; baseline start none → 2008-06-05; baseline finish none → 2008-06-06 |
| 31 | LVS |  |  |  |  |  |  | resources none → Jamie; baseline start none → 2008-06-09; baseline finish none → 2008-06-11 |
| 32 | Antennas |  |  |  |  |  |  | resources none → Jamie; baseline start none → 2008-06-12; baseline finish none → 2008-06-12 |
| 33 | Regenerate fill |  |  |  |  |  |  | resources none → Jamie; baseline start none → 2008-06-12; baseline finish none → 2008-06-13 |
| 34 | FDR |  |  |  |  | 1.2d → 2.2d |  | baseline start none → 2008-06-13; baseline finish none → 2008-06-13 |
| 35 | **Contingency** |  |  | 3w → 15d |  | 1.2d → 2.2d |  | was named Contingency & Final checks/changes; baseline start none → 2008-06-13; baseline finish none → 2008-07-10 |
| 38 | MPW Submission deadline |  |  |  |  |  | 35 → 36 | baseline start none → 2008-07-14; baseline finish none → 2008-07-14 |

## Version 3 (data date 2008-05-13, saved 2008-05-20, file ProjectPlanASIC1.1detailed_update200508.mpp)

Last finish stays 2008-07-14. Complete tasks 6 → 7.

Changed:

| ID | Task | Start | Finish | Complete | Total float |
| --- | --- | --- | --- | --- | --- |
| 12 | **Change preSample pixels to preShape** | 2008-05-20 A |  | 0% → 25% | 17.5d → 4d |
| 13 | Schematic changes | 2008-05-20 A |  | 0% → 50% | 17.5d → 4.75d |
| 14 | Layout changes | 2008-05-21 A |  | 0% → 25% | 17.5d → 4.5d |
| 15 | DRC | 2008-05-22 A |  | 0% → 50% | 17.5d → 4d |
| 17 | **Change test structures to preShape** |  |  | 13% → 75% | 17.5d → 5.25d |
| 18 | Schematics |  | 2008-05-14 A | 50% → 100% | 17.5d → none |
| 19 | Layout | 2008-05-15 A |  | 0% → 75% | 17.5d → 5.75d |
| 20 | LVS | 2008-05-19 A |  | 0% → 50% | 17.5d → 5.25d |
| 26 | **Top Level Changes & Checks** | 2008-05-28 A |  | 0% → 4% |  |
| 29 | Integrate new logic cells | 2008-06-03 A |  | 0% → 25% |  |
